# Esercitazione Pianificazione Progetto

Schedule from MS Project, 2020-11-06 to 2021-01-04, costs in $.

## Calendars

- Standard: Mon-Fri 08:00-12:00, 13:00-17:00; Sat-Sun off.

## Resources

| Resource | Rate | Cost per use |
| --- | --- | --- |
| Non assegnato |  |  |
| Analista | 40 | 30 |
| Analista Programmatore | 45 | 30 |
| Programmatore 1 | 40 | 35 |
| Programmatore Esperto WF | 40 | 45 |
| Programmatore 2 | 40 | 35 |

## Schedule

| ID | WBS | Task | Type | Duration | Start | Finish | Predecessors | Total slack | Constraint | Resources | Work | Cost |
| --- | --- | --- | --- | --- | --- | --- | --- | --- | --- | --- | --- | --- |
| 2 | 1 | **Progetto** |  | 41.38d | 2020-11-06 | 2021-01-04 |  | 0d |  |  | 598.32h | 26,247.03 |
| 3 | 1.1 | **Project Management** |  | 41.38d | 2020-11-06 | 2021-01-04 |  | 0d |  |  | 598.32h | 26,247.03 |
| 4 | 1.1.1 | **Iterazione 0** |  | 13.03d | 2020-11-06 | 2020-11-25 |  | 0d |  |  | 111.68h | 5,245.77 |
| 5 | 1.1.1.1 | **Raccolta Requisiti** |  | 6.91d | 2020-11-06 | 2020-11-16 |  | 0d |  |  | 56h | 2,609.8 |
| 6 | 1.1.1.1.1 | Requisiti Committente |  | 3.91d | 2020-11-06 | 2020-11-11 |  | 3d |  | Non assegnato [33%] | 8h | 329.9 |
| 7 | 1.1.1.1.2 | Requisiti Ufficio Contabilità |  | 1d | 2020-11-06 | 2020-11-06 |  | 5.91d |  | Analista Programmatore | 8h | 390 |
| 8 | 1.1.1.1.3 | Requisiti Ufficio Vendite |  | 1d | 2020-11-09 | 2020-11-09 |  | 4.91d | start no earlier than 2020-11-09 | Analista Programmatore | 8h | 390 |
| 9 | 1.1.1.1.4 | Requisiti Ufficio Magazzino |  | 1d | 2020-11-10 | 2020-11-10 |  | 3.91d | start no earlier than 2020-11-10 | Analista Programmatore | 8h | 390 |
| 10 | 1.1.1.1.5 | Requisiti Ufficio Direzione |  | 3.91d | 2020-11-11 | 2020-11-16 |  | 0d | start no earlier than 2020-11-11 | Non assegnato [33%] | 8h | 329.9 |
| 11 | 1.1.1.1.6 | Requisiti Ufficio Spedizioni |  | 1d | 2020-11-11 | 2020-11-11 |  | 2.91d | start no earlier than 2020-11-11 | Analista Programmatore | 8h | 390 |
| 12 | 1.1.1.1.7 | Requisiti Ufficio Fatturazione |  | 1d | 2020-11-12 | 2020-11-12 |  | 1.91d | start no earlier than 2020-11-12 | Analista Programmatore | 8h | 390 |
| 13 | 1.1.1.2 | Realizzazione documento requisiti |  | 2.97d | 2020-11-16 | 2020-11-19 | 5 | 0d | start no earlier than 2020-11-16 | Analista Programmatore; Non assegnato [33%] | 24h | 1,090.11 |
| 14 | 1.1.1.3 | Analisi documento requisiti con committente |  | 0.71d | 2020-11-19 | 2020-11-20 | 13 | 0d |  | Non assegnato [33%]; Analista Programmatore | 5.28h | 270.94 |
| 15 | 1.1.1.4 | Progettazione architetturale |  | 1.22d | 2020-11-20 | 2020-11-23 | 14 | 0d |  | Non assegnato [33%]; Analista Programmatore | 10.56h | 502 |
| 16 | 1.1.1.5 | Realizzazione documento delle specifiche |  | 1.23d | 2020-11-23 | 2020-11-25 | 15 | 0d |  | Non assegnato [33%]; Analista Programmatore | 7.92h | 386.46 |
| 17 | 1.1.1.6 | Preparazione ambiente di sviluppo |  | 0.45d | 2020-11-23 | 2020-11-25 | 15 | 0d | start no earlier than 2020-11-20 | Non assegnato [33%]; Analista Programmatore | 7.92h | 386.46 |
| 18 | 1.1.2 | Milestone | milestone | 2.48d | 2020-11-25 | 2020-11-27 | 16, 17 | 0d |  | Programmatore Esperto WF [50%] | 8h | 342.51 |
| 19 | 1.1.3 | **Iterazione Di sviluppo 1** |  | 7.97d | 2020-11-27 | 2020-12-09 |  | 0d |  |  | 172h | 7,361.58 |
| 20 | 1.1.3.1 | Pianificazione User Story |  | 1.48d | 2020-11-27 | 2020-11-30 | 18 | 0d |  | Analista Programmatore | 8h | 390 |
| 21 | 1.1.3.2 | Creazione Unit Test |  | 2.97d | 2020-12-01 | 2020-12-04 | 20 | 20.9d |  | Non assegnato [33%] | 8h | 329.9 |
| 22 | 1.1.3.3 | **Sviluppo del SW ed esecuzione Unit Test:** |  | 6.48d | 2020-12-01 | 2020-12-09 |  | 0d |  |  | 156h | 6,641.68 |
| 23 | 1.1.3.3.1 | Sviluppo SW Magazzino |  | 4.97d | 2020-12-01 | 2020-12-08 | 20 | 1d |  | Programmatore 1 | 40h | 1,635 |
| 24 | 1.1.3.3.2 | Sviluppo SW Vendite |  | 5.97d | 2020-12-01 | 2020-12-09 | 20 | 0d |  | Programmatore 2 | 48h | 1,955 |
| 25 | 1.1.3.3.3 | Sviluppo SW Contabilità |  | 4.47d | 2020-12-01 | 2020-12-07 | 20 | 2d |  | Programmatore Esperto WF [50%]; Analista Programmatore | 48h | 2,132.51 |
| 26 | 1.1.3.3.4 | Sviluppo SW Spedizioni |  | 2.48d | 2020-12-02 | 2020-12-04 | 20 | 2.48d | start no earlier than 2020-12-02 | Programmatore Esperto WF [50%]; Analista Programmatore | 20h | 919.17 |

| ID | WBS | Task | Duration | Start | Finish | Predecessors | Total slack | Free slack | Constraint | Resources | Work | Cost |
| --- | --- | --- | --- | --- | --- | --- | --- | --- | --- | --- | --- | --- |
| 27 | 1.1.4 | **Iterazione di Rilascio 1** | 3.97d | 2020-12-09 | 2020-12-15 |  | 0d |  |  |  | 32h | 1,420 |
| 28 | 1.1.4.1 | Test Funzionale #1 | 0.97d | 2020-12-09 | 2020-12-10 | 23, 24, 25, 26 | 0d |  |  | Programmatore 1; Analista Programmatore | 16h | 745 |
| 29 | 1.1.4.2 | Rilascio #1 | 2.48d | 2020-12-10 | 2020-12-15 | 28 | 11.45d | 0d |  | Programmatore 2 | 16h | 675 |
| 30 | 1.1.5 | Milestone | 2.48d | 2020-12-15 | 2020-12-17 | 29 | 11.45d |  |  | Programmatore Esperto WF | 16h | 685 |
| 31 | 1.1.6 | **Iterazione Di Sviluppo 2** | 8.97d | 2020-12-10 | 2020-12-23 |  | 0d |  |  |  | 174.64h | 7,388 |
| 32 | 1.1.6.1 | Pianificazione User Story | 1.48d | 2020-12-10 | 2020-12-14 | 28 | 0d |  |  | Non assegnato [33%] | 2.64h | 115.5 |
| 33 | 1.1.6.2 | Creazione Unit Test | 1.48d | 2020-12-14 | 2020-12-15 | 32 | 13.45d |  |  | Analista Programmatore | 8h | 390 |
| 34 | 1.1.6.3 | **Sviluppo del SW ed esecuzione Unit Test** | 7.48d | 2020-12-14 | 2020-12-23 |  | 0d |  |  |  | 164h | 6,882.5 |
| 35 | 1.1.6.3.1 | Sviluppo SW Vendite | 4.97d | 2020-12-14 | 2020-12-21 | 32 | 2d |  | start no earlier than 2020-12-09 | Analista Programmatore | 40h | 1,830 |
| 36 | 1.1.6.3.2 | Sviluppo SW Contabilità | 5.97d | 2020-12-14 | 2020-12-22 | 32 | 1d |  | start no earlier than 2020-12-08 | Programmatore 1 | 48h | 1,955 |
| 37 | 1.1.6.3.3 | Sviluppo SW Fatturazione | 5.97d | 2020-12-14 | 2020-12-22 | 32 | 1d |  | start no earlier than 2020-12-09 | Programmatore 2 | 48h | 1,955 |
| 38 | 1.1.6.3.4 | Sviluppo SW Direzione | 6.97d | 2020-12-14 | 2020-12-23 | 32 | 0d |  | start no earlier than 2020-12-09 | Programmatore Esperto WF [50%] | 28h | 1,142.5 |
| 39 | 1.1.7 | **Iterazione di Rilascio 2** | 4.97d | 2020-12-23 | 2020-12-30 |  | 0d |  | start no earlier than 2020-12-17 |  | 40h | 1,855 |
| 40 | 1.1.7.1 | Test Funzionale #2 | 2.97d | 2020-12-23 | 2020-12-29 | 35, 36, 37, 38 | 0d |  |  | Analista Programmatore | 24h | 1,110 |
| 41 | 1.1.7.2 | Rilascio #2 | 1.48d | 2020-12-29 | 2020-12-30 | 40 | 0d |  |  | Programmatore 1; Analista Programmatore | 16h | 745 |
| 42 | 1.1.8 | Milestone | 1.48d | 2020-12-30 | 2021-01-01 | 41 | 1d |  |  | Programmatore Esperto WF [50%] | 4h | 182.5 |
| 43 | 1.1.9 | Addestramento Utenza | 1.97d | 2020-12-30 | 2021-01-04 | 41 | 0d |  |  | Programmatore 1; Programmatore 2; Analista Programmatore | 40h | 1,766.67 |
